# Cedar Creek bridge widening. GENERATED FIXTURE -- NOT A REAL PROJECT. Produced by engine/tests/xerfuzz.py:claim_scenario(). One synthetic bridge-widening job in four exports -- a baseline and three progressed updates -- with a delay event whose basis is stated in the accompanying JSON. Every date in it was written by the generator. It is evidence that the commands run and what they say; it is not evidence about real schedules.

Schedule from Primavera P6, 2026-03-02 to 2026-06-09, data date 2026-06-01, costs in USD, A marks actual dates.
Must finish by 2026-08-14

## Resources

| Resource | Group |
| --- | --- |
| Civils crew | labor |
| Piling rig | equipment |

## Schedule

| ID | WBS | Activity | Type | Duration | Start | Finish | Predecessors | Complete | Planned start | Planned finish | Constraint | Calendar | Resources | Cost |
| --- | --- | --- | --- | --- | --- | --- | --- | --- | --- | --- | --- | --- | --- | --- |
| MOBILISE |  | Mobilise and set up site |  | 2.5d | 2026-03-02 A | 2026-03-04 A |  | 100% |  |  |  |  | Civils crew [20 h] | 1,900 |
| SURVEY |  | Set out and survey |  | 1.5d | 2026-03-05 A | 2026-03-06 A | MOBILISE | 100% |  |  |  |  | Civils crew [12 h] | 1,140 |
|  | SUB | **Substructure** |  |  | 2026-03-05 | 2026-05-01 |  |  |  |  |  |  |  |  |
| UTILITIES |  | Divert the 11kV duct bank |  | 7.5d | 2026-03-05 A | 2026-03-26 A | MOBILISE FS+1d | 100% | 2026-03-05 | 2026-03-16 |  |  | Civils crew [60 h] | 5,700 |
| EXCAVATE |  | Excavate north abutment |  | 5.5d | 2026-03-30 A | 2026-04-06 A | SURVEY, UTILITIES | 100% | 2026-03-18 | 2026-03-25 |  |  | Civils crew [44 h] | 4,180 |
| EXC-S |  | Excavate south abutment |  | 5.5d | 2026-04-01 A | 2026-04-08 A | EXCAVATE SS+2d | 100% | 2026-03-20 | 2026-03-27 |  |  | Civils crew [44 h] | 4,180 |
| PILING |  | Drive piles, north abutment |  | 9d | 2026-04-07 A | 2026-04-21 A | EXCAVATE | 100% | 2026-03-26 | 2026-04-07 |  | 6 day paving and piling | Piling rig [72 h] | 6,840 |
| PILING-S |  | Drive piles, south abutment |  | 9d | 2026-04-09 A | 2026-04-21 A | EXC-S | 100% | 2026-03-30 | 2026-04-09 |  | 6 day paving and piling | Piling rig [72 h] | 6,840 |
| PILECAP |  | North abutment pile cap |  | 4.5d | 2026-04-23 A | 2026-04-29 A | PILING | 100% | 2026-04-09 | 2026-04-15 |  |  | Civils crew [36 h] | 3,420 |
| PILECAP-S |  | South abutment pile cap |  | 4.5d | 2026-04-27 A | 2026-05-01 A | PILING-S | 100% | 2026-04-13 | 2026-04-17 |  |  | Civils crew [36 h] | 3,420 |
|  | SUP | **Superstructure** |  |  | 2026-04-30 | 2026-06-02 |  |  |  |  |  |  |  |  |
| COLUMNS |  | Columns and bearing shelves |  | 7d | 2026-04-30 A | 2026-05-08 A | PILECAP | 100% | 2026-04-16 | 2026-04-24 |  |  | Civils crew [56 h] | 5,320 |
| BEAMS |  | Set precast beams |  | 3d | 2026-05-12 A | 2026-05-14 A | COLUMNS, PILECAP-S | 100% | 2026-04-28 | 2026-04-30 |  | 6 day paving and piling | Piling rig [24 h] | 2,280 |
| DECK |  | Deck reinforcement and pour |  | 11d | 2026-05-15 A | 2026-05-29 A | BEAMS | 100% | 2026-05-01 | 2026-05-15 |  |  | Civils crew [88 h] | 8,360 |
| BARRIER |  | Barrier and parapet |  | 5d | 2026-05-27 | 2026-06-02 | CURE SS+3d |  |  |  |  |  | Civils crew [40 h] | 3,800 |
| CURE |  | Deck cure and strike |  | 7d | 2026-06-01 A | 2026-05-26 | DECK | 14% | 2026-05-18 | 2026-05-26 |  | 6 day paving and piling | Piling rig [56 h] | 5,320 |
|  | SURF | **Surfacing and opening** |  |  | 2026-05-27 | 2026-06-09 |  |  |  |  |  |  |  |  |
| PAVE |  | Surfacing |  | 3.5d | 2026-05-27 | 2026-06-01 | CURE |  |  |  |  | 6 day paving and piling | Piling rig [28 h] | 2,660 |
| STRIPE |  | Line marking and signs |  | 1.5d | 2026-06-02 | 2026-06-03 | PAVE FF |  |  |  |  |  | Civils crew [12 h] | 1,140 |
| PUNCH |  | Snagging |  | 2.5d | 2026-06-04 | 2026-06-08 | BARRIER, STRIPE FS+1d |  |  |  |  |  | Civils crew [20 h] | 1,900 |
| OPEN |  | Open to traffic | milestone | 0d | 2026-06-09 | 2026-06-09 | PUNCH |  |  |  | finish on or before 2026-08-14 |  |  |  |
